# Scrum Project Plan_SP

Schedule from MS Project, 2005-11-28 to 2006-05-10, A marks actual dates.
RIT

## Calendars

- Standard: Mon-Fri 08:00-12:00, 13:00-17:30; Sat-Sun off.

## Resources

| Resource |
| --- |
| Scrum Master |
| Product Owner |
| Project Team |
| Quality Assurance |
| Development |
| pro |

## Schedule

| ID | WBS | Task | Duration | Start | Finish | Predecessors | Complete | Remaining | Total slack | Free slack | Constraint | Resources | Work | Actual work |
| --- | --- | --- | --- | --- | --- | --- | --- | --- | --- | --- | --- | --- | --- | --- |
| 1 | 1 | **Peer Eveluation System** | 124.5d | 2005-11-28 A | 2006-05-10 |  | 30% | 87.22d | 0d |  |  |  | 1523.5h | 403.5h |
| 2 | 1.1 | **Requirements Elicitation** | 47.75d | 2005-11-28 A | 2006-01-27 A |  | 100% |  |  |  |  |  | 371.5h | 371.5h |
| 3 | 1.1.1 | Highlevel Requirements Elicitation and Analysis | 42.44d | 2005-11-28 A | 2006-01-20 A |  | 100% |  |  |  | start no earlier than 2005-11-28 | Project Team | 339.5h | 339.5h |
| 4 | 1.1.2 | Highlevel Requirements Prioritization | 2d | 2006-01-26 A | 2006-01-27 A | 3 | 100% |  |  |  | finish no earlier than 2006-01-27 | Scrum Master; Product Owner | 32h | 32h |
| 5 | 1.2 | **Analysis and Design** | 12.75d | 2006-01-27 A | 2006-02-14 | 2 | 17% | 10.62d | 0d |  |  |  | 96h | 16h |
| 6 | 1.2.1 | High Level Architecture | 10d | 2006-01-27 | 2006-02-10 | 2 |  |  | 12.19d | 0.75d |  | Project Team | 80h |  |
| 7 | 1.2.2 | **Database Design** | 2d | 2006-02-13 A | 2006-02-14 A | 6 | 100% |  |  |  |  |  | 16h | 16h |
| 8 | 1.2.2.1 | ER Modeling | 2d | 2006-02-13 A | 2006-02-14 A | 6 | 100% |  |  |  | finish no earlier than 2006-02-14 | Project Team | 16h | 16h |
| 9 | 1.3 | **Initial Setup** | 2d | 2006-01-27 A | 2006-01-31 A | 2 | 100% |  |  |  |  | Project Team | 16h | 16h |
| 10 | 1.3.1 | Database Setup | 2d | 2006-01-27 A | 2006-01-31 A |  | 100% |  |  |  |  |  |  |  |
| 11 | 1.3.2 | Server Setup (IIS) | 1d | 2006-01-27 A | 2006-01-30 A |  | 100% |  |  |  |  |  |  |  |
| 12 | 1.3.3 | Programming Environment | 1d | 2006-01-27 A | 2006-01-30 A |  | 100% |  |  |  |  |  |  |  |
| 13 | 1.4 | Interim Senior Project Presentation | 2d | 2006-02-14 | 2006-02-16 | 5 |  |  | 0d |  |  | Scrum Master | 16h |  |
| 14 | 1.5 | **Sprint 1** | 20d | 2006-02-16 | 2006-03-15 | 13 |  |  | 0d |  |  |  | 248h |  |
| 15 | 1.5.1 | **Sprint Planning** | 2d | 2006-02-16 | 2006-02-20 |  |  |  | 0d |  |  |  | 32h |  |
| 16 | 1.5.1.1 | Feature Negotiation | 2d | 2006-02-16 | 2006-02-20 |  |  |  | 0d |  |  | Scrum Master; Product Owner | 32h |  |
| 17 | 1.5.2 | **Implementation** | 6d | 2006-02-20 | 2006-02-28 | 15 |  |  | 0d |  |  |  | 48h |  |
| 18 | 1.5.2.1 | Activity 1 | 3d | 2006-02-20 | 2006-02-23 | 15 |  |  | 0d |  |  | Project Team | 24h |  |
| 19 | 1.5.2.2 | Activity 2 | 3d | 2006-02-23 | 2006-02-28 | 18 |  |  | 0d |  |  | Development | 24h |  |
| 20 | 1.5.3 | **Testing** | 11d | 2006-02-28 | 2006-03-14 | 17 |  |  | 0d |  |  |  | 160h |  |
| 21 | 1.5.3.1 | Unit Testing | 11d | 2006-02-28 | 2006-03-14 | 17 |  |  | 0d |  |  | Quality Assurance | 88h |  |
| 22 | 1.5.3.2 | Acceptance Testing | 5d | 2006-02-28 | 2006-03-07 | 17 |  |  | 6d |  |  | Quality Assurance | 40h |  |
| 23 | 1.5.3.3 | Usability Testing | 4d | 2006-02-28 | 2006-03-06 | 17 |  |  | 7d |  |  | Quality Assurance | 32h |  |
| 24 | 1.5.4 | Delivery | 1d | 2006-03-14 | 2006-03-15 | 20 |  |  | 0d |  |  | Project Team | 8h |  |

| ID | WBS | Task | Duration | Start | Finish | Predecessors | Total slack | Resources | Work |
| --- | --- | --- | --- | --- | --- | --- | --- | --- | --- |
| 25 | 1.6 | **Sprint 2** | 20d | 2006-03-15 | 2006-04-11 | 14 | 0d |  | 368h |
| 26 | 1.6.1 | **Sprint Planning** | 6d | 2006-03-15 | 2006-03-23 |  | 0d |  | 144h |
| 27 | 1.6.1.1 | Priority and new requirement analysis | 2d | 2006-03-15 | 2006-03-17 |  | 2d | Scrum Master; Product Owner; Project Team | 48h |
| 28 | 1.6.1.2 | Usability feedback analysis | 4d | 2006-03-15 | 2006-03-21 |  | 0d | Scrum Master; Project Team | 64h |
| 29 | 1.6.1.3 | Feature Negotiation | 2d | 2006-03-21 | 2006-03-23 | 27, 28 | 0d | Scrum Master; Product Owner | 32h |
| 30 | 1.6.2 | **Implementation** | 3d | 2006-03-23 | 2006-03-28 | 26 | 0d |  | 24h |
| 31 | 1.6.2.1 | Activity 1 | 3d | 2006-03-23 | 2006-03-28 | 26 | 0d | Development | 24h |
| 32 | 1.6.3 | **Testing** | 10d | 2006-03-28 | 2006-04-10 | 30 | 0d |  | 192h |
| 33 | 1.6.3.1 | Unit Testing | 10d | 2006-03-28 | 2006-04-10 | 30 | 0d | Quality Assurance | 80h |
| 34 | 1.6.3.2 | Acceptance Testing | 5d | 2006-03-28 | 2006-04-03 | 30 | 5d | Quality Assurance | 40h |
| 35 | 1.6.3.3 | Usability Testing | 4d | 2006-03-28 | 2006-03-31 | 30 | 6d | Quality Assurance | 32h |
| 36 | 1.6.3.4 | Integration Testing | 5d | 2006-03-28 | 2006-04-03 | 30 | 5d | Quality Assurance | 40h |
| 37 | 1.6.4 | Delivery | 1d | 2006-04-10 | 2006-04-11 | 32 | 0d | Project Team | 8h |
| 38 | 1.7 | **Sprint 3** | 22d | 2006-04-11 | 2006-05-10 | 25 | 0d |  | 408h |
| 39 | 1.7.1 | **Sprint Planning** | 6d | 2006-04-11 | 2006-04-19 |  | 0d |  | 144h |
| 40 | 1.7.1.1 | Priority and new requirement analysis | 2d | 2006-04-11 | 2006-04-13 |  | 2d | Scrum Master; Product Owner; Project Team | 48h |
| 41 | 1.7.1.2 | Usability feedback analysis | 4d | 2006-04-11 | 2006-04-17 |  | 0d | Scrum Master; Project Team | 64h |
| 42 | 1.7.1.3 | Feature Negotiation | 2d | 2006-04-17 | 2006-04-19 | 40, 41 | 0d | Scrum Master; Product Owner | 32h |
| 43 | 1.7.2 | **Implementation** | 3d | 2006-04-19 | 2006-04-21 | 39 | 0d |  | 24h |
| 44 | 1.7.2.1 | Activity 1 | 3d | 2006-04-19 | 2006-04-21 | 39 | 0d | Development | 24h |
| 45 | 1.7.3 | **Testing** | 10d | 2006-04-21 | 2006-05-05 | 43 | 0d |  | 216h |
| 46 | 1.7.3.1 | Unit Testing | 10d | 2006-04-21 | 2006-05-05 | 43 | 0d | Quality Assurance | 80h |
| 47 | 1.7.3.2 | Acceptance Testing | 5d | 2006-04-21 | 2006-04-28 | 43 | 5d | Quality Assurance | 40h |
| 48 | 1.7.3.3 | Usability Testing | 4d | 2006-04-21 | 2006-04-27 | 43 | 6d | Quality Assurance | 32h |
| 49 | 1.7.3.4 | Integration Testing | 8d | 2006-04-21 | 2006-05-03 | 43 | 2d | Quality Assurance | 64h |
| 50 | 1.7.4 | Final Delivery | 3d | 2006-05-05 | 2006-05-10 | 45 | 0d | Project Team | 24h |
